# Manpower Planning

Schedule from MS Project, 2008-09-02 to 2008-12-22, costs in $.

## Calendars

- Standard: Mon-Fri 08:00-12:00, 13:00-17:00; Sat-Sun off. Exceptions (off unless hours are given): 2008-11-27 to 2008-11-28.

## Resources

| Resource | Rate |
| --- | --- |
| Tom Johnson | 117 |
| Mario Cepeda | 114 |
| Rodney Post | 115 |
| Rhonda Witharm |  |
| M_Tech 1 |  |
| Autoclave |  |

## Schedule

| ID | WBS | Task | Type | Duration | Start | Finish | Predecessors | Total slack | Free slack | Resources | Work | Cost |
| --- | --- | --- | --- | --- | --- | --- | --- | --- | --- | --- | --- | --- |
| 1 | 1 | **PHENIX Stave** |  | 78d | 2008-09-02 | 2008-12-22 |  | 0d |  |  | 650.67h | 60,864 |
| 2 | 1.1 | **Thermal Tile** |  | 9d | 2008-09-02 | 2008-09-12 |  | 27d |  |  | 24h | 2,808 |
| 3 | 1.1.1 | Thermal Tile Panel |  | 1d | 2008-09-02 | 2008-09-02 |  | 27d | 0d | Tom Johnson | 8h | 936 |
| 4 | 1.1.2 | Waterjet Cut |  | 1d | 2008-09-08 | 2008-09-08 | 3FS+3d | 69d | 0d |  |  |  |
| 5 | 1.1.3 | Measure Tiles |  | 2d | 2008-09-09 | 2008-09-10 | 4 | 69d | 0d | Tom Johnson | 16h | 1,872 |
| 6 | 1.1.4 | Clean and Dry |  | 1d | 2008-09-12 | 2008-09-12 | 5FS+1d | 69d |  |  |  |  |
| 7 | 1.2 | **Omega** |  | 40d | 2008-09-02 | 2008-10-27 |  | 0d |  |  | 16h | 936 |
| 8 | 1.2.1 | Tool Drawing Issued | milestone | 1d | 2008-09-02 | 2008-09-02 |  | 0d |  |  |  |  |
| 9 | 1.2.2 | Machined Part |  | 25d | 2008-09-08 | 2008-10-10 | 8FS+3d | 0d |  |  |  |  |
| 10 | 1.2.3 | Cut and Kit Plys |  | 1d | 2008-09-03 | 2008-09-03 | 3 | 27d |  |  |  |  |
| 11 | 1.2.4 | Test Laminates |  | 1d | 2008-10-13 | 2008-10-13 | 10, 9 | 0d |  | Tom Johnson; Autoclave | 16h | 936 |
| 12 | 1.2.5 | Meaure Parts |  | 2d | 2008-10-14 | 2008-10-15 | 11 | 0d |  |  |  |  |
| 13 | 1.2.6 | **Tooling Adjustment** |  | 8d | 2008-10-16 | 2008-10-27 | 12 | 19.67d |  |  |  |  |
| 14 | 1.2.6.1 | Re-Machine Tool |  | 5d | 2008-10-16 | 2008-10-22 |  | 19.67d | 0d |  |  |  |
| 15 | 1.2.6.2 | Test Laminates |  | 1d | 2008-10-23 | 2008-10-23 | 14 | 19.67d | 0d |  |  |  |
| 16 | 1.2.6.3 | Measure Parts |  | 2d | 2008-10-24 | 2008-10-27 | 15 | 19.67d | 0d |  |  |  |
| 17 | 1.3 | **Omega Production** |  | 20d | 2008-10-28 | 2008-11-24 |  | 18d |  |  | 182.67h | 7,956 |
| 18 | 1.3.1 | Cut and Kit Plys |  | 1d | 2008-10-28 | 2008-10-28 | 16 | 19.67d | 0d | Tom Johnson | 8h | 936 |
| 19 | 1.3.2 | Batch 1 |  | 1d | 2008-10-29 | 2008-10-29 | 12, 18 | 19.67d | 0d | Tom Johnson [50%]; Autoclave | 12h | 468 |
| 20 | 1.3.3 | Batch 2 |  | 1d | 2008-10-30 | 2008-10-30 | 19 | 19.67d | 0d | Tom Johnson [50%]; Autoclave | 12h | 468 |
| 21 | 1.3.4 | Batch 3 |  | 2d | 2008-10-31 | 2008-11-03 | 20 | 18.67d | 0d | Tom Johnson [50%]; Autoclave | 12h | 468 |
| 22 | 1.3.5 | Batch 4 |  | 1d | 2008-11-04 | 2008-11-04 | 21 | 18.67d | 0d | Tom Johnson [50%]; Autoclave | 12h | 468 |
| 23 | 1.3.6 | Batch 5 |  | 1d | 2008-11-05 | 2008-11-05 | 22 | 18.67d | 0d | Tom Johnson [50%]; Autoclave | 12h | 468 |
| 24 | 1.3.7 | Batch 6 |  | 1d | 2008-11-06 | 2008-11-06 | 23 | 18.67d | 0d | Tom Johnson [50%]; Autoclave | 12h | 468 |
| 25 | 1.3.8 | Batch 7 |  | 2d | 2008-11-07 | 2008-11-10 | 24 | 18.67d | 0d | Tom Johnson [50%]; Autoclave | 12h | 468 |
| 26 | 1.3.9 | Batch 8 |  | 1d | 2008-11-11 | 2008-11-11 | 25 | 18.67d | 0d | Tom Johnson [50%]; Autoclave | 12h | 468 |
| 27 | 1.3.10 | Batch 9 |  | 1d | 2008-11-12 | 2008-11-12 | 26 | 18.67d | 0d | Tom Johnson [50%]; Autoclave | 12h | 468 |
| 28 | 1.3.11 | Batch 10 |  | 1d | 2008-11-13 | 2008-11-13 | 27 | 18.67d | 0d | Tom Johnson [50%]; Autoclave | 6.67h | 468 |
| 29 | 1.3.12 | Batch 11 |  | 2d | 2008-11-14 | 2008-11-17 | 28 | 18d | 0d | Tom Johnson [50%]; Autoclave | 12h | 468 |
| 30 | 1.3.13 | Batch 12 |  | 1d | 2008-11-18 | 2008-11-18 | 29 | 18d | 0d | Tom Johnson [50%]; Autoclave | 12h | 468 |
| 31 | 1.3.14 | Batch 13 |  | 1d | 2008-11-19 | 2008-11-19 | 30 | 18d | 0d | Tom Johnson [50%]; Autoclave | 12h | 468 |
| 32 | 1.3.15 | Batch 14 |  | 1d | 2008-11-20 | 2008-11-20 | 31 | 18d | 0d | Tom Johnson [50%]; Autoclave | 12h | 468 |
| 33 | 1.3.16 | Batch 15 |  | 2d | 2008-11-21 | 2008-11-24 | 32 | 18d |  | Tom Johnson [50%]; Autoclave | 12h | 468 |

| ID | WBS | Task | Type | Duration | Start | Finish | Predecessors | Total slack | Free slack | Resources | Work | Cost |
| --- | --- | --- | --- | --- | --- | --- | --- | --- | --- | --- | --- | --- |
| 34 | 1.4 | **Stave Assembly** |  | 46d | 2008-10-15 | 2008-12-22 |  | 0d |  |  | 428h | 49,164 |
| 35 | 1.4.1 | **Peek Supports** |  | 21d | 2008-10-16 | 2008-11-13 |  | 4d |  |  |  |  |
| 36 | 1.4.1.1 | Peek Support Drawing Issued |  | 1d | 2008-10-16 | 2008-10-16 | 12 | 4d | 0d |  |  |  |
| 37 | 1.4.1.2 | First Articles |  | 2d | 2008-10-21 | 2008-10-22 | 36FS+2d | 4d |  |  |  |  |
| 38 | 1.4.1.3 | Production Release | milestone | 1d | 2008-11-07 | 2008-11-07 | 46 | 25d | 0d |  |  |  |
| 39 | 1.4.1.4 | Final production |  | 4d | 2008-11-10 | 2008-11-13 | 38 | 25d |  |  |  |  |
| 40 | 1.4.2 | **Assembly Tooling** |  | 9d | 2008-10-15 | 2008-10-28 |  | 0d |  |  | 16h | 1,840 |
| 41 | 1.4.2.1 | Drawings Issued | milestone | 0d | 2008-10-15 | 2008-10-15 | 12 | 0d |  |  |  |  |
| 42 | 1.4.2.2 | Part Fabrication |  | 5d | 2008-10-20 | 2008-10-24 | 41FS+2d | 0d |  |  |  |  |
| 43 | 1.4.2.3 | Tooling Assembly |  | 2d | 2008-10-27 | 2008-10-28 | 42 | 0d |  | Rodney Post | 16h | 1,840 |
| 44 | 1.4.3 | **First Article Assembly** |  | 13d | 2008-10-29 | 2008-11-14 |  | 0d |  |  | 52h | 6,004 |
| 45 | 1.4.3.1 | First Article Assembly |  | 5d | 2008-10-29 | 2008-11-04 | 37, 43 | 0d |  | Rodney Post | 40h | 4,600 |
| 46 | 1.4.3.2 | First Article Survey |  | 2d | 2008-11-05 | 2008-11-06 | 45 | 0d |  |  |  |  |
| 47 | 1.4.3.3 | Thermal Cycle |  | 1d | 2008-11-07 | 2008-11-07 | 46 | 24d | 0d | Tom Johnson [50%] | 4h | 468 |
| 48 | 1.4.3.4 | First Article Test Finish |  | 2d | 2008-11-13 | 2008-11-14 | 47FS+3d | 24d |  | Tom Johnson [50%] | 8h | 936 |
| 49 | 1.4.4 | **Production Assembly Batches** |  | 30d | 2008-11-07 | 2008-12-22 |  | 0d |  |  | 360h | 41,320 |
| 50 | 1.4.4.1 | **Batch 1** |  | 4d | 2008-11-07 | 2008-11-12 |  | 0d |  |  | 32h | 3,664 |
| 51 | 1.4.4.1.1 | Omega bond |  | 2d | 2008-11-07 | 2008-11-10 | 46 | 0d |  | Rodney Post | 16h | 1,840 |
| 52 | 1.4.4.1.2 | Block Bond |  | 2d | 2008-11-11 | 2008-11-12 | 51 | 8d | 0d | Mario Cepeda | 16h | 1,824 |
| 53 | 1.4.4.2 | **Batch 2** |  | 4d | 2008-11-11 | 2008-11-14 |  | 0d |  |  | 32h | 3,664 |
| 54 | 1.4.4.2.1 | Omega Bond |  | 2d | 2008-11-11 | 2008-11-12 | 51 | 0d |  | Rodney Post | 16h | 1,840 |
| 55 | 1.4.4.2.2 | Block Bond |  | 2d | 2008-11-13 | 2008-11-14 | 54, 52 | 8d | 0d | Mario Cepeda | 16h | 1,824 |
| 56 | 1.4.4.3 | **Batch 1/2 QA** |  | 9d | 2008-11-17 | 2008-12-01 |  | 15d |  |  | 8h | 936 |
| 57 | 1.4.4.3.1 | Survey Batch 1/2 |  | 1d | 2008-11-17 | 2008-11-17 | 55 | 15d | 0d |  |  |  |
| 58 | 1.4.4.3.2 | Thermal Cycle |  | 1d | 2008-11-18 | 2008-11-18 | 57 | 15d | 0d | Tom Johnson [50%] | 4h | 468 |
| 59 | 1.4.4.3.3 | Pressure Cycle |  | 1d | 2008-11-26 | 2008-11-26 | 58FS+5d | 15d | 0d | Tom Johnson [50%] | 4h | 468 |
| 60 | 1.4.4.3.4 | Survey |  | 1d | 2008-12-01 | 2008-12-01 | 59 | 15d |  |  |  |  |

| ID | WBS | Task | Duration | Start | Finish | Predecessors | Total slack | Free slack | Resources | Work | Cost |
| --- | --- | --- | --- | --- | --- | --- | --- | --- | --- | --- | --- |
| 61 | 1.4.4.4 | **Batch 3** | 4d | 2008-11-13 | 2008-11-18 |  | 0d |  |  | 32h | 3,664 |
| 62 | 1.4.4.4.1 | Omega bond | 2d | 2008-11-13 | 2008-11-14 | 54 | 0d |  | Rodney Post | 16h | 1,840 |
| 63 | 1.4.4.4.2 | Block Bond | 2d | 2008-11-17 | 2008-11-18 | 55 | 8d | 0d | Mario Cepeda | 16h | 1,824 |
| 64 | 1.4.4.5 | **Batch 4** | 4d | 2008-11-17 | 2008-11-20 |  | 0d |  |  | 32h | 3,664 |
| 65 | 1.4.4.5.1 | Omega Bond | 2d | 2008-11-17 | 2008-11-18 | 62 | 0d |  | Rodney Post | 16h | 1,840 |
| 66 | 1.4.4.5.2 | Block Bond | 2d | 2008-11-19 | 2008-11-20 | 63, 65 | 8d | 0d | Mario Cepeda | 16h | 1,824 |
| 67 | 1.4.4.6 | **Batch 3/4 QA** | 8d | 2008-11-21 | 2008-12-04 |  | 12d |  |  | 8h | 936 |
| 68 | 1.4.4.6.1 | Survey Batch 3/4 | 1d | 2008-11-21 | 2008-11-21 | 66 | 12d | 0d |  |  |  |
| 69 | 1.4.4.6.2 | Thermal Cycle | 0.5d | 2008-11-24 | 2008-11-24 | 68 | 12d | 0d | Tom Johnson | 4h | 468 |
| 70 | 1.4.4.6.3 | Pressure Cycle | 0.5d | 2008-12-03 | 2008-12-03 | 69FS+5d | 12d | 0d | Tom Johnson | 4h | 468 |
| 71 | 1.4.4.6.4 | Survey | 1d | 2008-12-04 | 2008-12-04 | 70 | 12d |  |  |  |  |
| 72 | 1.4.4.7 | **Batch 5** | 4d | 2008-11-19 | 2008-11-24 |  | 0d |  |  | 32h | 3,664 |
| 73 | 1.4.4.7.1 | Omega bond | 2d | 2008-11-19 | 2008-11-20 | 65 | 0d |  | Rodney Post | 16h | 1,840 |
| 74 | 1.4.4.7.2 | Block Bond | 2d | 2008-11-21 | 2008-11-24 | 73, 66 | 8d | 0d | Mario Cepeda | 16h | 1,824 |
| 75 | 1.4.4.8 | **Batch 6** | 4d | 2008-11-21 | 2008-11-26 |  | 0d |  |  | 32h | 3,664 |
| 76 | 1.4.4.8.1 | Omega Bond | 2d | 2008-11-21 | 2008-11-24 | 73 | 0d |  | Rodney Post | 16h | 1,840 |
| 77 | 1.4.4.8.2 | Block Bond | 2d | 2008-11-25 | 2008-11-26 | 76, 74 | 8d | 0d | Mario Cepeda | 16h | 1,824 |
| 78 | 1.4.4.9 | **Batch 5/6 QA** | 8d | 2008-12-01 | 2008-12-10 |  | 8d |  |  | 8h | 936 |
| 79 | 1.4.4.9.1 | Survey Batch 5/6 | 1d | 2008-12-01 | 2008-12-01 | 77 | 8d | 0d |  |  |  |
| 80 | 1.4.4.9.2 | Thermal Cycle | 0.5d | 2008-12-02 | 2008-12-02 | 79 | 8d | 0d | Tom Johnson | 4h | 468 |
| 81 | 1.4.4.9.3 | Pressure Cycle | 0.5d | 2008-12-09 | 2008-12-09 | 80FS+5d | 8d | 0d | Tom Johnson | 4h | 468 |
| 82 | 1.4.4.9.4 | Survey | 1d | 2008-12-10 | 2008-12-10 | 81 | 8d |  |  |  |  |
| 83 | 1.4.4.10 | **Batch 7** | 4d | 2008-11-25 | 2008-12-02 |  | 0d |  |  | 32h | 3,664 |
| 84 | 1.4.4.10.1 | Omega bond | 2d | 2008-11-25 | 2008-11-26 | 76 | 0d |  | Rodney Post | 16h | 1,840 |
| 85 | 1.4.4.10.2 | Block Bond | 2d | 2008-12-01 | 2008-12-02 | 84 | 4d | 0d | Mario Cepeda | 16h | 1,824 |

| ID | WBS | Task | Duration | Start | Finish | Predecessors | Total slack | Free slack | Resources | Work | Cost |
| --- | --- | --- | --- | --- | --- | --- | --- | --- | --- | --- | --- |
| 86 | 1.4.4.11 | **Batch 8** | 4d | 2008-12-01 | 2008-12-04 |  | 0d |  |  | 32h | 3,664 |
| 87 | 1.4.4.11.1 | Omega Bond | 2d | 2008-12-01 | 2008-12-02 | 84 | 0d |  | Rodney Post | 16h | 1,840 |
| 88 | 1.4.4.11.2 | Block Bond | 2d | 2008-12-03 | 2008-12-04 | 87, 85 | 4d | 0d | Mario Cepeda | 16h | 1,824 |
| 89 | 1.4.4.12 | **Batch 7/8 QA** | 8d | 2008-12-05 | 2008-12-16 |  | 4d |  |  | 8h | 936 |
| 90 | 1.4.4.12.1 | Survey Batch 7/8 | 1d | 2008-12-05 | 2008-12-05 | 88 | 4d | 0d |  |  |  |
| 91 | 1.4.4.12.2 | Thermal Cycle | 0.5d | 2008-12-08 | 2008-12-08 | 90 | 4d | 0d | Tom Johnson | 4h | 468 |
| 92 | 1.4.4.12.3 | Pressure Cycle | 0.5d | 2008-12-15 | 2008-12-15 | 91FS+5d | 4d | 0d | Tom Johnson | 4h | 468 |
| 93 | 1.4.4.12.4 | Survey | 1d | 2008-12-16 | 2008-12-16 | 92 | 4d |  |  |  |  |
| 94 | 1.4.4.13 | **Batch 9** | 4d | 2008-12-03 | 2008-12-08 |  | 0d |  |  | 32h | 3,664 |
| 95 | 1.4.4.13.1 | Omega bond | 2d | 2008-12-03 | 2008-12-04 | 87 | 0d |  | Rodney Post | 16h | 1,840 |
| 96 | 1.4.4.13.2 | Block Bond | 2d | 2008-12-05 | 2008-12-08 | 95, 88 | 10d |  | Mario Cepeda | 16h | 1,824 |
| 97 | 1.4.4.14 | **Batch 10** | 4d | 2008-12-05 | 2008-12-10 |  | 0d |  |  | 32h | 3,664 |
| 98 | 1.4.4.14.1 | Omega Bond | 2d | 2008-12-05 | 2008-12-08 | 95 | 0d |  | Rodney Post | 16h | 1,840 |
| 99 | 1.4.4.14.2 | Block Bond | 2d | 2008-12-09 | 2008-12-10 | 98 | 0d |  | Mario Cepeda | 16h | 1,824 |
| 100 | 1.4.4.15 | **Batch 9/10 QA** | 8d | 2008-12-11 | 2008-12-22 |  | 0d |  |  | 8h | 936 |
| 101 | 1.4.4.15.1 | Survey Batch 9/10 | 1d | 2008-12-11 | 2008-12-11 | 99 | 0d |  |  |  |  |
| 102 | 1.4.4.15.2 | Thermal Cycle | 0.5d | 2008-12-12 | 2008-12-12 | 101 | 0d |  | Tom Johnson | 4h | 468 |
| 103 | 1.4.4.15.3 | Pressure Cycle | 0.5d | 2008-12-19 | 2008-12-19 | 102FS+5d | 0d |  | Tom Johnson | 4h | 468 |
| 104 | 1.4.4.15.4 | Survey | 1d | 2008-12-22 | 2008-12-22 | 103 | 0d |  |  |  |  |
